# PROGRACION ABAD PUELL

Schedule from MS Project, 2022-12-01 to 2023-09-26.

## Calendars

- Estándar: Mon-Sat 08:00-13:00, 14:00-17:00; Sun off.

## Schedule

| ID | WBS | Task | Type | Duration | Start | Finish | Predecessors | Total slack | Free slack | Cost | Text1 |
| --- | --- | --- | --- | --- | --- | --- | --- | --- | --- | --- | --- |
| 1 | 1 | **"RECONSTRUCCIÓN DE PISTAS Y VEREDAS EN LA CALLE TARAPACA, AV. PIURA, AV. ARICA, CALLE 24 DE JULIO Y PROLONGACION TARAPACA DEL BARRIO SAN JOSE DEL DISTRITO DE TUMBES - PROVINCIA DE TUMBES - DEPARTAMENTO DE TUMBES"** |  | 257d | 2022-12-01 | 2023-09-26 |  | 0d |  | 12,250,543.91 |  |
| 2 | 1.1 | INICIO DEL PROYECTO | milestone | 0d | 2022-12-01 | 2022-12-01 |  | 0d |  |  |  |
| 3 | 1.2 | **PAVIMENTO RIGIDO** |  | 257d | 2022-12-01 | 2023-09-26 |  | 0d |  | 8,974,144.99 | 01 |
| 4 | 1.2.1 | **OBRAS PROVISIONALES** |  | 250d | 2022-12-01 | 2023-09-18 |  | 0d |  | 115,155.25 | 01 |
| 5 | 1.2.1.1 | SUMINISTRO Y COLOCACION DE CARTEL DE OBRA (5.60x3.40m) |  | 1d | 2022-12-01 | 2022-12-01 | 2SS | 254d | 0d | 1,185.16 | 01.01 |
| 6 | 1.2.1.2 | CASETA PARA ALMACEN, OFICINA Y GUARDIANIA |  | 2d | 2022-12-01 | 2022-12-02 | 5SS | 254d |  | 5,605.2 | 01.01.01 |
| 7 | 1.2.1.3 | MANTENIMIENTO DEL TRANSITO Y SEGURIDAD VIAL |  | 250d | 2022-12-01 | 2023-09-18 | 2SS | 0d |  | 24,509.4 | 01.01.02 |
| 8 | 1.2.1.4 | PLAN DE MONITOREO DE IMPACTO AMBIENTAL |  | 250d | 2022-12-01 | 2023-09-18 | 7SS | 0d |  | 35,060 | 01.01.03 |
| 9 | 1.2.1.5 | **ELABORACION, IMPLEMENTACION Y ADMINISTRACION DEL PLAN DE SEGURIDAD Y SALUD EN EL TRABAJO** |  | 250d | 2022-12-01 | 2023-09-18 |  | 0d |  | 48,795.49 | 01.01.04 |
| 10 | 1.2.1.5.1 | EQUIPO DE PROTECCION COLECCTIVA |  | 250d | 2022-12-01 | 2023-09-18 | 8SS | 0d |  | 5,732.6 | 01.01.05 |
| 11 | 1.2.1.5.2 | EQUIPO DE PROTECCION INDIVIDUAL |  | 250d | 2022-12-01 | 2023-09-18 | 10SS | 0d |  | 23,140 | 01.01.05.01 |
| 12 | 1.2.1.5.3 | **PLAN PARA LA PREVENCION Y CONTROL ANTE LA COVID-19 EN OBRA** |  | 250d | 2022-12-01 | 2023-09-18 |  | 0d |  | 19,922.89 | 01.01.05.02 |
| 13 | 1.2.1.5.3.1 | EQUIPO DE PROTECCION INDIVIDUAL PARA PERSONAL DE OBRA |  | 250d | 2022-12-01 | 2023-09-18 | 11SS | 0d |  | 6,300 | 01.01.05.03 |
| 14 | 1.2.1.5.3.2 | EQUIPO DE PROTECCION INDIVIDUAL PARA DIRECCION DE OBRA |  | 250d | 2022-12-01 | 2023-09-18 | 13SS | 0d |  | 1,260 | 01.01.05.03.01 |
| 15 | 1.2.1.5.3.3 | EQUIPO DE PROTECCION INDIVIDUAL PARA PERSONAL DE SALUD |  | 250d | 2022-12-01 | 2023-09-18 | 14SS | 0d |  | 2,726 | 01.01.05.03.02 |
| 16 | 1.2.1.5.3.4 | KIT PARA LAVADO Y DESINFECCION DE PERSONAL |  | 250d | 2022-12-01 | 2023-09-18 | 15SS | 0d |  | 2,772 | 01.01.05.03.03 |
| 17 | 1.2.1.5.3.5 | EQUIPAMIENTO PARA VIGILANCIA DE LA SALUD DEL TRABAJADOR |  | 250d | 2022-12-01 | 2023-09-18 | 16SS | 0d |  | 3,982.8 | 01.01.05.03.04 |
| 18 | 1.2.1.5.3.6 | IMPLEMENTACION DE AREA DE TRIAJE (CONTROL PREVIO) |  | 250d | 2022-12-01 | 2023-09-18 | 17SS | 0d |  | 2,882.09 | 01.01.05.03.05 |
| 19 | 1.2.2 | **TRABAJOS PRELIMINARES** |  | 250d | 2022-12-01 | 2023-09-18 |  | 0d |  | 199,250.94 | 01.01.05.03.06 |
| 20 | 1.2.2.1 | TRAZO, NIVELACION Y REPLANTEO |  | 250d | 2022-12-01 | 2023-09-18 | 18SS | 0d |  | 67,336.94 | 01.02 |
| 21 | 1.2.2.2 | MOVILIZACION Y DESMOVILIZACION DE EQUIPO |  | 250d | 2022-12-01 | 2023-09-18 | 20SS | 0d |  | 13,600 | 01.02.01 |
| 22 | 1.2.2.3 | **DEMOLICIONES** |  | 20d | 2022-12-03 | 2022-12-26 |  | 0d |  | 118,314 | 01.02.02 |
| 23 | 1.2.2.3.1 | DEMOLICION DE PAVIMENTO EXISTENTE EN MAL ESTADO. |  | 20d | 2022-12-03 | 2022-12-26 | 21SS+2d | 0d |  | 69,627.52 | 01.02.03 |
| 24 | 1.2.2.3.2 | EXTRACCION DE ADOQUIN DE CONCRETO EXISTENTE MANUAL |  | 20d | 2022-12-03 | 2022-12-26 | 23SS | 0d |  | 48,686.48 | 01.02.03.01 |

| ID | WBS | Task | Duration | Start | Finish | Predecessors | Total slack | Free slack | Cost | Text1 |
| --- | --- | --- | --- | --- | --- | --- | --- | --- | --- | --- |
| 25 | 1.2.3 | **PAVIMENTACION** | 249d | 2022-12-06 | 2023-09-21 |  | 0d |  | 7,684,752.98 | 01.02.03.02 |
| 26 | 1.2.3.1 | **MOVIMIENTO DE TIERRAS** | 158d | 2022-12-06 | 2023-06-07 |  | 0d |  | 2,986,368.78 | 01.03 |
| 27 | 1.2.3.1.1 | CORTE CON MAQUINARIA PARA CONFORMACION DE ESTRUCTURA DE PAVIMENTO | 50d | 2022-12-06 | 2023-02-01 | 24SS+2d | 0d |  | 188,429.25 | 01.03.01 |
| 28 | 1.2.3.1.2 | EXCAVACION MANUAL P/ UÑA EN LOSA EN PAVIMENTO | 10d | 2023-04-18 | 2023-04-28 | 188FS-8d | 0d |  | 1,312.94 | 01.03.01.01 |
| 29 | 1.2.3.1.3 | PERFILADO Y COMPACTACION DE SUB RASANTE EN PAVIMENTO | 15d | 2023-04-20 | 2023-05-06 | 28SS+2d | 0d |  | 109,000.71 | 01.03.01.02 |
| 30 | 1.2.3.1.4 | MEJORAMIENTO DE SUB RASANTE CON MATERIAL DE PRESTAMO OVER DE 6" A 8" E=0.30M | 25d | 2023-04-22 | 2023-05-20 | 29SS+2d | 0d |  | 1,077,984.95 | 01.03.01.03 |
| 31 | 1.2.3.1.5 | MEJORAMIENTO DE SUB RASANTE CON MATERIAL DE PRESTAMO HORMIGON GRUESO E=0.20M | 25d | 2023-04-22 | 2023-05-20 | 30SS | 0d |  | 479,816.85 | 01.03.01.04 |
| 32 | 1.2.3.1.6 | SUMINISTRO E INSTALACION DE GEOTEXTIL NO TEJIDO 300 GR/M2 | 15d | 2023-05-10 | 2023-05-26 | 31FS-10d | 0d |  | 278,112.1 | 01.03.01.05 |
| 33 | 1.2.3.1.7 | COLOCACION, CONFORMACION Y COMPACTACION DE SUB BASE (50% AFIRMADO + 50% HORMIGON ) E=0.20M | 20d | 2023-05-16 | 2023-06-07 | 32SS+5d | 0d |  | 441,880.32 | 01.03.01.06 |
| 34 | 1.2.3.1.8 | ELIMINACIÓN DE MATERIAL EXCEDENTE D. PROM 5 KM DE LA OBRA | 20d | 2023-01-16 | 2023-02-07 | 27FS-15d | 197d |  | 409,831.66 | 01.03.01.07 |
| 35 | 1.2.3.2 | **PAVIMENTO RIGIDO** | 85d | 2023-05-27 | 2023-09-02 |  | 0d |  | 3,600,297.33 | 01.03.01.08 |
| 36 | 1.2.3.2.1 | LOSA DE RODADURA, CONCRETO F`C=280 Kg/cm2, e=0.20 m.- CEMENTO TIPO MS | 40d | 2023-06-26 | 2023-08-10 | 46FS-20d | 0d |  | 1,685,401.88 | 01.03.02 |
| 37 | 1.2.3.2.2 | LOSA DE RODADURA, CONCRETO F'C=300/ KG/CM2, e=0.25m. - CEMENTO TIPO MS | 40d | 2023-06-26 | 2023-08-10 | 36SS | 0d |  | 1,825,147.46 | 01.03.02.01 |
| 38 | 1.2.3.2.3 | ENCOFRADO Y DESENCOFRADO DE LOSA DE RODADURA | 35d | 2023-05-27 | 2023-07-06 | 33SS+10d | 0d |  | 3,218.69 | 01.03.02.02 |
| 39 | 1.2.3.2.4 | UÑA EN TERMINO DE LOSA DE 0.20X0.50m CONCRETO F'C=280 KG/CM2 | 40d | 2023-06-26 | 2023-08-10 | 36SS | 4d | 0d | 15,197.95 | 01.03.02.03 |
| 40 | 1.2.3.2.5 | CURADO DE LOSA DE RODADURA | 60d | 2023-06-26 | 2023-09-02 | 36SS | 19d |  | 71,331.35 | 01.03.02.04 |
| 41 | 1.2.3.3 | **JUNTAS** | 70d | 2023-06-02 | 2023-08-22 |  | 0d |  | 1,075,872.43 | 01.03.02.05 |
| 42 | 1.2.3.3.1 | CORTE Y SELLADO DE JUNTAS DE CONTRACCIÓN e= 6mm | 40d | 2023-06-02 | 2023-07-18 | 38SS+5d | 0d |  | 299,416.9 | 01.03.03 |
| 43 | 1.2.3.3.2 | JUNTA TRANSVERSAL CON DOWEL LISO H=10CM - VARILLA LISA Ø 1" X 41CM @ 30CM INC/ CANASTILLA ELECTROSOLDADA | 40d | 2023-06-02 | 2023-07-18 | 42SS | 0d |  | 253,067.04 | 01.03.03.01 |
| 44 | 1.2.3.3.3 | JUNTA TRANSVERSAL CON DOWEL LISO H=12.5CM - VARILLA LISA Ø 1 1/4" X 46 CM @ 30CM INC/ CANASTILLA ELECTROSOLDADA | 40d | 2023-06-02 | 2023-07-18 | 43SS | 0d |  | 319,935.24 | 01.03.03.02 |
| 45 | 1.2.3.3.4 | JUNTA LONGITUDINAL- BARRA DE AMARRE CORRUGADA H=10 CM Ø 1/2"X95CM @ 76CM INC/ CANASTILLA ELECTROSOLDADA | 40d | 2023-06-02 | 2023-07-18 | 44SS | 0d |  | 86,343.47 | 01.03.03.03 |
| 46 | 1.2.3.3.5 | JUNTA LONGITUDINAL- BARRA DE AMARRE CORRUGADA H=12.5 CM Ø 5/8"X95CM @ 91CM INC/ CANASTILLA ELECTROSOLDADA | 40d | 2023-06-02 | 2023-07-18 | 45SS | 0d |  | 82,340.5 | 01.03.03.04 |
| 47 | 1.2.3.3.6 | JUNTA DE CONSTRUCCION ASFALTICA E=1" | 30d | 2023-07-19 | 2023-08-22 | 39FS-20d | 4d | 0d | 34,769.28 | 01.03.03.05 |
| 48 | 1.2.3.4 | **SARDINEL DELIMITADOR** | 36d | 2023-08-11 | 2023-09-21 |  | 4d |  | 22,214.44 | 01.03.03.06 |
| 49 | 1.2.3.4.1 | PINTADO DE FRANJAS EN PAVIMENTO | 8d | 2023-08-28 | 2023-09-05 | 50FS-4d | 4d | 0d | 1,830.44 | 01.03.04 |
| 50 | 1.2.3.4.2 | PINTADO DE LINEAS DE PASO PEATONAL | 18d | 2023-08-11 | 2023-08-31 | 47FS-10d | 4d | 0d | 13,927.76 | 01.03.04.01 |
| 51 | 1.2.3.4.3 | PINTADO DE LINEAS DE PARE | 18d | 2023-08-11 | 2023-08-31 | 50SS | 21d |  | 2,118.7 | 01.03.04.02 |
| 52 | 1.2.3.4.4 | PINTADO DE FLECHAS DIRECCIONALES SEGUN TIPO | 20d | 2023-08-30 | 2023-09-21 | 49SS+2d | 4d |  | 4,337.54 | 01.03.04.03 |

| ID | WBS | Task | Duration | Start | Finish | Predecessors | Total slack | Free slack | Cost | Text1 |
| --- | --- | --- | --- | --- | --- | --- | --- | --- | --- | --- |
| 53 | 1.2.4 | **VEREDAS, RAMPAS Y SARDINELES DE CONFINAMIENTO** | 45d | 2023-08-04 | 2023-09-25 |  | 0d |  | 787,318.83 | 01.03.04.04 |
| 54 | 1.2.4.1 | **MOVIMIENTO DE TIERRAS** | 30d | 2023-08-04 | 2023-09-07 |  | 0d |  | 275,062.11 | 01.04 |
| 55 | 1.2.4.1.1 | EXCAVACION MANUAL P/VEREDAS, RAMPAS Y SARDINELES | 8d | 2023-08-07 | 2023-08-15 | 37FS-4d | 0d |  | 71,387.86 | 01.04.01 |
| 56 | 1.2.4.1.2 | PERFILADO NIVELACION Y COMPACTACION DE SUB RASANTE DE VEREDAS, RAMPAS | 18d | 2023-08-04 | 2023-08-24 | 55FS-10d | 0d |  | 20,690.28 | 01.04.01.01 |
| 57 | 1.2.4.1.3 | COLOCACION, NIVELACION Y COMPACTACION DE CAPA DE HORMIGON E=0.30M | 18d | 2023-08-07 | 2023-08-26 | 56SS+2d | 0d |  | 123,498.43 | 01.04.01.02 |
| 58 | 1.2.4.1.4 | COLOCACION, NIVELACION Y COMPACTACION DE BASE AFIRMADO E=0.10M | 20d | 2023-08-10 | 2023-09-01 | 57FS-15d | 0d |  | 35,162.75 | 01.04.01.03 |
| 59 | 1.2.4.1.5 | ELIMINACIÓN DE MATERIAL EXCEDENTE D. PROM 5 KM DE LA OBRA | 20d | 2023-08-16 | 2023-09-07 | 55 | 15d |  | 24,322.79 | 01.04.01.04 |
| 60 | 1.2.4.2 | **OBRAS DE CONCRETO SIMPLE** | 33d | 2023-08-17 | 2023-09-23 |  | 2d |  | 444,118.38 | 01.04.01.05 |
| 61 | 1.2.4.2.1 | VEREDAS Y RAMPAS DE CONCRETO F'C=175 KG/CM2 ACABADO SEMI PULIDO INC/ BRUÑAS | 20d | 2023-08-26 | 2023-09-18 | 58FS-6d | 0d |  | 231,559.56 | 01.04.02 |
| 62 | 1.2.4.2.2 | ENCOFRADO Y DESENCOFRADO DE VEREDAS | 25d | 2023-08-26 | 2023-09-23 | 61SS | 0d |  | 16,531.68 | 01.04.02.01 |
| 63 | 1.2.4.2.3 | SARDINEL DE CONFINAMIENTO DE 0.20X0.60M DE CONCRETO F'C=175 KG/CM2, INC/ ENCOFRADO | 25d | 2023-08-26 | 2023-09-23 | 62SS | 0d |  | 37,189.25 | 01.04.02.02 |
| 64 | 1.2.4.2.4 | SADINEL DE CONFINAMIENTO EN VEREDAS DE 0.20X0.40M DE CONCRETO F'C=175 KG/CM2, INC/ ENCOFRADO | 25d | 2023-08-26 | 2023-09-23 | 63SS | 0d |  | 148,663.99 | 01.04.02.03 |
| 65 | 1.2.4.2.5 | CURADO DE LOSA DE VEREDAS | 25d | 2023-08-17 | 2023-09-14 | 61FS-28d | 10d |  | 10,173.9 | 01.04.02.04 |
| 66 | 1.2.4.3 | **JUNTAS** | 8d | 2023-09-13 | 2023-09-21 |  | 4d |  | 9,045 | 01.04.02.05 |
| 67 | 1.2.4.3.1 | JUNTA ASFALTICA EN VEREDAS E=1" | 8d | 2023-09-13 | 2023-09-21 | 61FS-5d | 4d |  | 9,045 | 01.04.03 |
| 68 | 1.2.4.4 | **OTROS** | 18d | 2023-09-05 | 2023-09-25 |  | 0d |  | 59,093.34 | 01.04.03.01 |
| 69 | 1.2.4.4.1 | PINTADO DE BORDE DE SARDINEL EN VEREDAS CON PINTURA DE TRAFICO | 5d | 2023-09-20 | 2023-09-25 | 70FS-5d | 0d |  | 48,992.52 | 01.04.04 |
| 70 | 1.2.4.4.2 | TARRAJEO DE SARDINEL DE CONFINAMIENTO DE 0.20X0.60M, PROP: 1 :4 | 18d | 2023-09-05 | 2023-09-25 | 64FS-17d | 0d |  | 7,860.3 | 01.04.04.01 |
| 71 | 1.2.4.4.3 | REPOSICION DE CONEXIONES DOMICILIARIAS DE AGUA POTABLE | 5d | 2023-09-20 | 2023-09-25 | 69SS | 0d |  | 703.2 | 01.04.04.02 |
| 72 | 1.2.4.4.4 | REPOSICION DE CONEXIONES DOMICILIARIAS DE DESAGUE | 5d | 2023-09-20 | 2023-09-25 | 71SS | 0d |  | 1,537.32 | 01.04.04.03 |
| 73 | 1.2.5 | **TRABAJOS COMPLEMENTARIOS** | 253d | 2022-12-06 | 2023-09-26 |  | 0d |  | 187,666.99 | 01.05 |
| 74 | 1.2.5.1 | LIMPIEZA FINAL GENERAL DE LA OBRA | 3d | 2023-09-23 | 2023-09-26 | 72FS-2d | 0d |  | 17,935.54 | 01.05.01 |
| 75 | 1.2.5.2 | BOMBEO DE AGUA PROVINIENTE DE NIVEL FREATICO | 84d | 2022-12-06 | 2023-03-13 | 27SS | 168d | 0d | 79,351.2 | 01.05.02 |
| 76 | 1.2.5.3 | TRANSPORTE DE MATERIALES A OBRA | 50d | 2022-12-06 | 2023-02-01 | 27SS | 202d |  | 90,380.25 | 01.05.03 |

| ID | WBS | Task | Duration | Start | Finish | Predecessors | Total slack | Free slack | Cost | Text1 |
| --- | --- | --- | --- | --- | --- | --- | --- | --- | --- | --- |
| 77 | 1.3 | **REDES DE AGUA Y ALCANTARILLADO** | 126d | 2022-12-01 | 2023-04-26 |  | 4d |  | 3,276,398.92 | 02 |
| 78 | 1.3.1 | **TRABAJOS PRELIMINARES** | 110d | 2022-12-06 | 2023-04-12 |  | 0d |  | 29,550.03 | 02.01 |
| 79 | 1.3.1.1 | TRAZO Y REPLANTEO INICIAL DEL PROYECTO, PARA LÍNEAS-REDES | 110d | 2022-12-06 | 2023-04-12 | 27SS | 0d |  | 7,486.63 | 02.01.01 |
| 80 | 1.3.1.2 | CERCO DE MALLA HDP DE 1 M ALTURA PARA LÍMITE DE SEGURIDAD DE OBRA | 26d | 2022-12-06 | 2023-01-04 | 79SS | 0d |  | 6,461.1 | 02.01.02 |
| 81 | 1.3.1.3 | CONO FIBRA VIDRIO FOSFORESCENTE P/DESVÍO DE TRÁNSITO S/D (PROV. DURANTE OBRA) | 26d | 2022-12-06 | 2023-01-04 | 80SS | 0d |  | 507 | 02.01.03 |
| 82 | 1.3.1.4 | TRANQUERA TIPO TIJERA DE 2,40 X 1,20 M PARA SEÑAL PELIGRO (PROV. DURANTE OBRA) | 26d | 2022-12-06 | 2023-01-04 | 81SS | 0d |  | 2,887.14 | 02.01.04 |
| 83 | 1.3.1.5 | PUENTE DE MADERA PARA PASE PEATONAL SOBRE ZANJA S/D (PROV. DURANTE OBRA) | 26d | 2022-12-06 | 2023-01-04 | 82SS | 0d |  | 4,855.2 | 02.01.05 |
| 84 | 1.3.1.6 | PUENTE DE MADERA PARA PASE VEHICULAR SOBRE ZANJA S/D (PROV. DURANTE OBRA) | 26d | 2022-12-06 | 2023-01-04 | 83SS | 0d |  | 7,352.96 | 02.01.06 |
| 85 | 1.3.2 | **RED DE AGUA POTABLE** | 121d | 2022-12-01 | 2023-04-20 |  | 136d |  | 985,589.24 | 02.02 |
| 86 | 1.3.2.1 | **MOVIMIENTO DE TIERRAS** | 93d | 2022-12-26 | 2023-04-12 |  | 136d |  | 410,383.8 | 02.02.01 |
| 87 | 1.3.2.1.1 | **EXCAVACION DE ZANJAS** | 20d | 2022-12-26 | 2023-01-17 |  | 136d |  | 25,474.15 | 02.02.01.01 |
| 88 | 1.3.2.1.1.1 | EXCAV. ZANJA(MÁQ)P/TUB T-SATURADO DN 110-200MM DE 1,50 M PROF. | 20d | 2022-12-26 | 2023-01-17 | 156FS-15d | 135d | 0d | 25,474.15 | 02.02.01.01.01 |
| 89 | 1.3.2.1.2 | **REFINE Y CONFORMACIÓN DE ZANJAS** | 20d | 2022-12-26 | 2023-01-17 |  | 138d |  | 35,565.84 | 02.02.01.02 |
| 90 | 1.3.2.1.2.1 | REFINE Y NIVEL DE ZANJA T-SATURADO P/TUB. DN 110-200MM PARA TODA PROF. | 20d | 2022-12-26 | 2023-01-17 | 88SS | 137d | 0d | 7,896.99 | 02.02.01.02.01 |
| 91 | 1.3.2.1.2.2 | DRENAJE DE ZANJAS C/BOMBEO P/DEPRIMIR NAPA FREÁTICA | 20d | 2022-12-26 | 2023-01-17 | 90SS | 137d | 0d | 27,668.85 | 02.02.01.02.02 |
| 92 | 1.3.2.1.3 | **CAMA DE APOYO PARA PROTECCION DE TUBERIAS** | 62d | 2022-12-31 | 2023-03-13 |  | 138d |  | 131,035.11 | 02.02.01.03 |
| 93 | 1.3.2.1.3.1 | CAMA DE OVER E=0.30 ZANJA P/TUB DN 110-200MM | 20d | 2022-12-31 | 2023-01-23 | 91FS-15d | 137d | 0d | 67,839.62 | 02.02.01.03.01 |
| 94 | 1.3.2.1.3.2 | CAMA DE ARENA E=0.10M. ZANJA P/TUB DN 110-200MM | 8d | 2023-01-18 | 2023-01-26 | 93FS-5d | 137d | 0d | 15,931.14 | 02.02.01.03.02 |
| 95 | 1.3.2.1.3.3 | CAMA DE ARENA E=0.20 SCT P/TUBERÍA DN 110-200MM | 15d | 2023-02-24 | 2023-03-13 | 111SS+3d | 137d | 0d | 47,264.35 | 02.02.01.03.03 |
| 96 | 1.3.2.1.4 | **RELLENO, APISONADO Y COMPACTACION ZANJAS** | 15d | 2023-03-27 | 2023-04-12 |  | 138d |  | 137,854.34 | 02.02.01.04 |
| 97 | 1.3.2.1.4.1 | RELLENO C/MATERIAL DE PRÉSTAMO DN 110-200MM. 1,50 M PROF. | 15d | 2023-03-27 | 2023-04-12 | 131FS-10d | 137d | 0d | 137,854.34 | 02.02.01.04.01 |
| 98 | 1.3.2.1.5 | **ACARREO Y ELIMINACION MATERIAL EXCEDENTE** | 6d | 2023-01-13 | 2023-01-19 |  | 214d |  | 80,454.36 | 02.02.01.05 |
| 99 | 1.3.2.1.5.1 | ACARREO INTERNO, MATERIAL PROCEDEDENTE DE LAS EXCAVACIONES EN ZONA ALEDAÑA | 6d | 2023-01-13 | 2023-01-19 | 88FS-4d | 213d | 0d | 42,450.34 | 02.02.01.05.01 |
| 100 | 1.3.2.1.5.2 | ELIMINACIÓN DE MATERIAL EXCEDENTE D. PROM 5 KM DE LA OBRA | 6d | 2023-01-13 | 2023-01-19 | 99SS | 213d |  | 38,004.02 | 02.02.01.05.02 |

| ID | WBS | Task | Duration | Start | Finish | Predecessors | Total slack | Free slack | Cost | Text1 |
| --- | --- | --- | --- | --- | --- | --- | --- | --- | --- | --- |
| 101 | 1.3.2.2 | **SUMINISTRO E INSTALACION DE TUBERIA** | 25d | 2023-01-20 | 2023-02-17 |  | 138d |  | 196,640.1 | 02.02.02 |
| 102 | 1.3.2.2.1 | TUBERÍA DE PVC-U UF NTP ISO 1452 PN 10 DN 110MM INCL. ANILLO + 2% DESPERDICIOS | 25d | 2023-01-20 | 2023-02-17 | 94SS+2d | 137d | 0d | 140,293.46 | 02.02.02.01 |
| 103 | 1.3.2.2.2 | TUBERÍA DE PVC-U UF NTP ISO 1452 PN 10 DN 160MM INCL. ANILLO + 2% DESPERDICIOS | 25d | 2023-01-20 | 2023-02-17 | 102SS | 137d | 0d | 39,653.85 | 02.02.02.02 |
| 104 | 1.3.2.2.3 | TUBERÍA DE PVC-U UF NTP ISO 1452 PN 10 DN 200MM INCL. ANILLO + 2% DESPERDICIOS | 25d | 2023-01-20 | 2023-02-17 | 103SS | 137d | 0d | 9,672.77 | 02.02.02.03 |
| 105 | 1.3.2.2.4 | INSTALACIÓN DE TUBERÍA PVC P/AGUA POTAB. DN 110MM NTP 1452 | 25d | 2023-01-20 | 2023-02-17 | 104SS | 137d | 0d | 5,806.06 | 02.02.02.04 |
| 106 | 1.3.2.2.5 | INSTALACIÓN DE TUBERÍA PVC P/AGUA POTAB. DN 160MM NTP 1452 | 25d | 2023-01-20 | 2023-02-17 | 105SS | 137d | 0d | 986.84 | 02.02.02.05 |
| 107 | 1.3.2.2.6 | INSTALACIÓN DE TUBERÍA PVC P/AGUA POTAB. DN 200MM NTP 1452 | 25d | 2023-01-20 | 2023-02-17 | 106SS | 137d | 0d | 227.12 | 02.02.02.06 |
| 108 | 1.3.2.3 | **PRUEBAS HIDRAULICAS** | 5d | 2023-02-21 | 2023-02-25 |  | 138d |  | 18,849.76 | 02.02.03 |
| 109 | 1.3.2.3.1 | PRUEBA HIDRÁULICA Y DESINFECCIÓN DE TUBERÍA AGUA POTAB. DN 110MM NTP ISO 1452 PN 10 | 5d | 2023-02-21 | 2023-02-25 | 128FS-3d | 137d | 0d | 16,047.08 | 02.02.03.01 |
| 110 | 1.3.2.3.2 | PRUEBA HIDRÁULICA Y DESINFECCIÓN DE TUBERÍA AGUA POTAB. DN 160MM NTP ISO 1452 PN 10 | 5d | 2023-02-21 | 2023-02-25 | 109SS | 137d | 0d | 2,387.37 | 02.02.03.02 |
| 111 | 1.3.2.3.3 | PRUEBA HIDRÁULICA Y DESINFECCIÓN DE TUBERÍA AGUA POTAB. DN 200MM NTP ISO 1452 PN 10 | 5d | 2023-02-21 | 2023-02-25 | 110SS | 137d | 0d | 415.31 | 02.02.03.03 |
| 112 | 1.3.2.4 | **SUMINISTRO E INSTALACION DE ACCESORIOS** | 25d | 2023-01-26 | 2023-02-23 |  | 138d |  | 12,971.84 | 02.02.04 |
| 113 | 1.3.2.4.1 | TEE DE PVC - U UNIÓN FLEXIBLE NTP ISO 1452 PN 10 - DN 110MM | 25d | 2023-01-26 | 2023-02-23 | 107SS+5d | 137d | 0d | 383.92 | 02.02.04.01 |
| 114 | 1.3.2.4.2 | TEE DE PVC - U UNIÓN FLEXIBLE NTP ISO 1452 PN 10 - DN 160MM | 25d | 2023-01-26 | 2023-02-23 | 113SS | 137d | 0d | 1,622.2 | 02.02.04.02 |
| 115 | 1.3.2.4.3 | CODO DE PVC-U UNIÓN FLEXIBLE NTP ISO 1452 PN 10 DE 90° DN 110MM | 25d | 2023-01-26 | 2023-02-23 | 114SS | 137d | 0d | 568.83 | 02.02.04.03 |
| 116 | 1.3.2.4.4 | CODO DE PVC-U UNIÓN FLEXIBLE NTP ISO 1452 PN 10 DE 90° DN 160MM | 25d | 2023-01-26 | 2023-02-23 | 115SS | 137d | 0d | 396.9 | 02.02.04.04 |
| 117 | 1.3.2.4.5 | REDUCCIÓN DE PVC-U UNIÓN FLEXIBLE NTP ISO 1452 PN 10 DN 160-110MM | 25d | 2023-01-26 | 2023-02-23 | 116SS | 137d | 0d | 1,996.25 | 02.02.04.05 |
| 118 | 1.3.2.4.6 | ACOPLE METÁLICO DE AMPLIO RANGO PARA TUBERÍA DN100MM (R=110/127,8) | 25d | 2023-01-26 | 2023-02-23 | 117SS | 137d | 0d | 2,030.85 | 02.02.04.06 |
| 119 | 1.3.2.4.7 | ACOPLE METÁLICO DE AMPLIO RANGO PARA TUBERÍA DN 150MM (R= 160/181,6) | 25d | 2023-01-26 | 2023-02-23 | 118SS | 137d | 0d | 286.65 | 02.02.04.07 |
| 120 | 1.3.2.4.8 | ACOPLE METÁLICO DE AMPLIO RANGO PARA TUBERÍA DN 200MM (R= 200/235) | 25d | 2023-01-26 | 2023-02-23 | 119SS | 137d | 0d | 793.3 | 02.02.04.08 |
| 121 | 1.3.2.4.9 | INSTALACIÓN DE ACCESORIOS DE P.V.C UF-SP DN 110 - 200MM | 25d | 2023-01-26 | 2023-02-23 | 120SS | 137d | 0d | 2,441.61 | 02.02.04.09 |
| 122 | 1.3.2.4.10 | CONCRETO F'C 140 KG/CM2 PARA ANCLAJES DE ACCESORIOS DN 110-160MM. | 25d | 2023-01-26 | 2023-02-23 | 121SS | 137d | 0d | 2,451.33 | 02.02.04.10 |
| 123 | 1.3.2.5 | **SUMINISTRO E INSTALACION DE VALVULAS** | 25d | 2023-01-26 | 2023-02-23 |  | 138d |  | 7,038.43 | 02.02.05 |
| 124 | 1.3.2.5.1 | VÁLVULA CPTA.CC, HO.DÚCTIL CIERRE ELÁST. VÁSTAGO ACERO INOXIDABLE DN 100MM | 25d | 2023-01-26 | 2023-02-23 | 122SS | 137d | 0d | 3,256.75 | 02.02.05.01 |
| 125 | 1.3.2.5.2 | INSTALACIÓN DE VÁLVULA COMPUERTA DN 110 MM INCL. REGISTRO | 25d | 2023-01-26 | 2023-02-23 | 124SS | 137d | 0d | 3,781.68 | 02.02.05.02 |

| ID | WBS | Task | Duration | Start | Finish | Predecessors | Total slack | Free slack | Cost | Text1 |
| --- | --- | --- | --- | --- | --- | --- | --- | --- | --- | --- |
| 126 | 1.3.2.6 | **SUMINISTRO E INSTALACION DE GRIFO CONTRA INCENDIO** | 25d | 2023-01-26 | 2023-02-23 |  | 138d |  | 3,950.56 | 02.02.06 |
| 127 | 1.3.2.6.1 | SUMINISTRO DE GRIFO CONTRA INCENDIO TIPO POSTE DE 2 BOCAS | 25d | 2023-01-26 | 2023-02-23 | 125SS | 137d | 0d | 2,981.06 | 02.02.06.01 |
| 128 | 1.3.2.6.2 | INSTALACIÓN DE GRIFO CONTRA INCENDIO TIPO POSTE DE 2 BOCAS INCL. ANCLAJE | 25d | 2023-01-26 | 2023-02-23 | 127SS | 137d | 0d | 969.5 | 02.02.06.02 |
| 129 | 1.3.2.7 | **CONEXIONES DOMICILIARIAS DE AGUA** | 26d | 2023-03-08 | 2023-04-06 |  | 138d |  | 271,038.3 | 02.02.07 |
| 130 | 1.3.2.7.1 | CONEXIONES DOMICILIARIAS PARA AGUA POTABLE TUB. HDP DN 15 - 110MM. | 26d | 2023-03-08 | 2023-04-06 | 136SS+5d | 137d | 0d | 259,677.6 | 02.02.07.01 |
| 131 | 1.3.2.7.2 | CONEXIONES DOMICILIARIAS PARA AGUA POTABLE TUB. HDP DN 15 - 160MM. | 26d | 2023-03-08 | 2023-04-06 | 130SS | 137d | 0d | 11,360.7 | 02.02.07.02 |
| 132 | 1.3.2.8 | **ROTURA Y REPOSICION DE PAVIMENTOS** | 119d | 2022-12-01 | 2023-04-18 |  | 138d |  | 57,231.99 | 02.02.08 |
| 133 | 1.3.2.8.1 | CORTE Y ROTURA PAVIMENTO RÍGIDO-CONCRETO DE 6" (INCL. PERFILADO BORDES) | 3d | 2023-01-14 | 2023-01-17 | 88FS-3d | 215d |  | 6,006.75 | 02.02.08.01 |
| 134 | 1.3.2.8.2 | REPOSICIÓN DE PAVIMENTO RÍGIDO (INC.SUB BASE,BASE.) EN CRUCES DE TUBERÍAS | 4d | 2022-12-01 | 2022-12-05 |  | 252d |  | 23,788.72 | 02.02.08.02 |
| 135 | 1.3.2.8.3 | CORTE DE VEREDA P/CONEXIÓN DOMICILIARIA | 12d | 2023-03-02 | 2023-03-15 | 95FS-10d | 137d | 0d | 8,911.99 | 02.02.08.03 |
| 136 | 1.3.2.8.4 | DEMOLICIÓN DE VEREDA P/CONEXIÓN DOMICILIARIA | 12d | 2023-03-02 | 2023-03-15 | 135SS | 137d | 0d | 2,982.99 | 02.02.08.04 |
| 137 | 1.3.2.8.5 | CONCRETO F'C 175 kg/cm2 PARA VEREDAS E=10cm. (CEMENTO MS) | 10d | 2023-04-07 | 2023-04-18 | 97FS-5d | 137d |  | 15,541.54 | 02.02.08.05 |
| 138 | 1.3.2.9 | **EMPALMES A RED EXISTENTES** | 100d | 2022-12-26 | 2023-04-20 |  | 136d |  | 7,484.46 | 02.02.09 |
| 139 | 1.3.2.9.1 | EMPALME C/ INSERCIÓN DE TUBERÍA A LÍNEAS DE AGUA POTABLE DN 110MM | 25d | 2023-01-20 | 2023-02-17 | 102SS | 188d | 0d | 868.32 | 02.02.09.01 |
| 140 | 1.3.2.9.2 | EMPALME C/ INSERCIÓN DE TUBERÍA A LÍNEAS DE AGUA POTABLE DN 160MM | 25d | 2023-01-20 | 2023-02-17 | 139SS | 188d | 0d | 1,216.38 | 02.02.09.02 |
| 141 | 1.3.2.9.3 | EMPALME C/ INSERCIÓN DE TUBERÍA A LÍNEAS DE AGUA POTABLE DN 200MM | 25d | 2023-01-20 | 2023-02-17 | 140SS | 188d |  | 226.34 | 02.02.09.03 |
| 142 | 1.3.2.9.4 | COLOCACION DE TUBERIA DE PVC-Ø2" PROVISIONAL DE AGUA PARA CONTINUIDAD DEL SERVICIO | 100d | 2022-12-26 | 2023-04-20 | 88SS | 135d |  | 5,173.42 | 02.02.09.04 |
| 143 | 1.3.3 | **RED DE ALCANTARILLADO** | 120d | 2022-12-08 | 2023-04-26 |  | 0d |  | 2,261,259.65 | 02.03 |
| 144 | 1.3.3.1 | **MOVIMIENTO DE TIERRAS** | 120d | 2022-12-08 | 2023-04-26 |  | 0d |  | 1,132,649.32 | 02.03.01 |
| 145 | 1.3.3.1.1 | **EXCAVACION DE ZANJAS** | 30d | 2022-12-08 | 2023-01-11 |  | 0d |  | 105,483.39 | 02.03.01.01 |
| 146 | 1.3.3.1.1.1 | EXCAVACIONES EN TERRENO SATURADO A MÁQUINA P/BUZÓN | 30d | 2022-12-08 | 2023-01-11 | 84SS+2d | 0d |  | 4,495.08 | 02.03.01.01.01 |
| 147 | 1.3.3.1.1.2 | EXCAV. ZANJA(MÁQ)P/TUB T-SATURADO DN 200-250 de 1,51 m a 2,00 m Prof. | 30d | 2022-12-08 | 2023-01-11 | 146SS | 0d |  | 8,029.05 | 02.03.01.01.02 |
| 148 | 1.3.3.1.1.3 | EXCAV. ZANJA(MÁQ)P/TUB T-SATURADO DN 200-250 de 2,01 m a 2,50 m Prof. | 30d | 2022-12-08 | 2023-01-11 | 147SS | 0d |  | 11,344.88 | 02.03.01.01.03 |
| 149 | 1.3.3.1.1.4 | EXCAV. ZANJA(MÁQ)P/TUB T-SATURADO DN 200-250 de 2,51 m a 3,00 m Prof. | 30d | 2022-12-08 | 2023-01-11 | 148SS | 0d |  | 14,901.79 | 02.03.01.01.04 |
| 150 | 1.3.3.1.1.5 | EXCAV. ZANJA(MÁQ)P/TUB T-SATURADO DN 200-250 de 3,01 m a 3,50 m Prof. | 30d | 2022-12-08 | 2023-01-11 | 149SS | 0d |  | 6,148.08 | 02.03.01.01.05 |
| 151 | 1.3.3.1.1.6 | EXCAV. ZANJA(MÁQ)P/TUB T-SATURADO DN 200-250 de 3,51 m a 4.00 m Prof. | 30d | 2022-12-08 | 2023-01-11 | 150SS | 0d |  | 9,621.16 | 02.03.01.01.06 |
| 152 | 1.3.3.1.1.7 | EXCAV. ZANJA(MÁQ)P/TUB T-SATURADO DN 200-250 DE 4.01 M A 4.50 M PROF. | 30d | 2022-12-08 | 2023-01-11 | 151SS | 0d |  | 7,938.59 | 02.03.01.01.07 |
| 153 | 1.3.3.1.1.8 | EXCAV. ZANJA(MÁQ)P/TUB T-SATURADO DN 315-400 DE 4,51 M A 5,00 M PROF. | 30d | 2022-12-08 | 2023-01-11 | 152SS | 0d |  | 4,749.03 | 02.03.01.01.08 |
| 154 | 1.3.3.1.1.9 | EXCAV. ZANJA(MÁQ)P/TUB T-SATURADO DN 315-400 DE 5,01 M A 5,50 M PROF. | 30d | 2022-12-08 | 2023-01-11 | 153SS | 0d |  | 12,626.87 | 02.03.01.01.09 |
| 155 | 1.3.3.1.1.10 | EXCAV. ZANJA(MÁQ)P/TUB T-SATURADO DN 315-400 DE 5,51 M A 6,00 M PROF. | 30d | 2022-12-08 | 2023-01-11 | 154SS | 0d |  | 16,534.12 | 02.03.01.01.10 |
| 156 | 1.3.3.1.1.11 | EXCAV. ZANJA(MÁQ)P/TUB T-SATURADO DN 315-400 de 6,01 m a 6.50 m Prof. | 30d | 2022-12-08 | 2023-01-11 | 155SS | 0d |  | 9,094.74 | 02.03.01.01.11 |

| ID | WBS | Task | Duration | Start | Finish | Predecessors | Total slack | Cost | Text1 |
| --- | --- | --- | --- | --- | --- | --- | --- | --- | --- |
| 157 | 1.3.3.1.2 | **REFINE Y CONFORMACIÓN DE ZANJAS** | 30d | 2022-12-20 | 2023-01-23 |  | 0d | 51,476.73 | 02.03.01.02 |
| 158 | 1.3.3.1.2.1 | REFINE Y NIVEL DE ZANJA T-SATURADO P/TUB. DN 200 - 250 para toda Prof. | 30d | 2022-12-20 | 2023-01-23 | 170SS+5d | 0d | 5,764.41 | 02.03.01.02.01 |
| 159 | 1.3.3.1.2.2 | REFINE Y NIVEL DE ZANJA T-SATURADO P/TUB. DN 315 - 400 para toda Prof. | 30d | 2022-12-20 | 2023-01-23 | 158SS | 0d | 2,380.59 | 02.03.01.02.02 |
| 160 | 1.3.3.1.2.3 | DRENAJE DE ZANJAS C/BOMBEO P/DEPRIMIR NAPA FREÁTICA | 30d | 2022-12-20 | 2023-01-23 | 159SS | 0d | 43,331.73 | 02.03.01.02.03 |
| 161 | 1.3.3.1.3 | **ENTIBADO DE ZANJAS** | 30d | 2022-12-14 | 2023-01-17 |  | 0d | 154,915.02 | 02.03.01.03 |
| 162 | 1.3.3.1.3.1 | ENTIBADO DE ZANJA DE 2.01 HASTA 2.50 m | 30d | 2022-12-14 | 2023-01-17 | 156SS+5d | 0d | 19,458.51 | 02.03.01.03.01 |
| 163 | 1.3.3.1.3.2 | ENTIBADO DE ZANJA DE 2.51 HASTA 3.00 m | 30d | 2022-12-14 | 2023-01-17 | 162SS | 0d | 22,668.49 | 02.03.01.03.02 |
| 164 | 1.3.3.1.3.3 | ENTIBADO DE ZANJA DE 3.01 HASTA 3.50 m | 30d | 2022-12-14 | 2023-01-17 | 163SS | 0d | 8,417.73 | 02.03.01.03.03 |
| 165 | 1.3.3.1.3.4 | ENTIBADO DE ZANJA DE 3.51 HASTA 4.00 m | 30d | 2022-12-14 | 2023-01-17 | 164SS | 0d | 21,004.22 | 02.03.01.03.04 |
| 166 | 1.3.3.1.3.5 | ENTIBADO DE ZANJA DE 4.01 HASTA 4.50 M | 30d | 2022-12-14 | 2023-01-17 | 165SS | 0d | 17,676.21 | 02.03.01.03.05 |
| 167 | 1.3.3.1.3.6 | ENTIBADO DE ZANJA DE 4.51 HASTA 5.00 m | 30d | 2022-12-14 | 2023-01-17 | 166SS | 0d | 11,103.53 | 02.03.01.03.06 |
| 168 | 1.3.3.1.3.7 | ENTIBADO DE ZANJA DE 5.01 HASTA 5.50 m | 30d | 2022-12-14 | 2023-01-17 | 167SS | 0d | 20,125.72 | 02.03.01.03.07 |
| 169 | 1.3.3.1.3.8 | ENTIBADO DE ZANJA DE 5.51 HASTA 6.00 M | 30d | 2022-12-14 | 2023-01-17 | 168SS | 0d | 22,882.31 | 02.03.01.03.08 |
| 170 | 1.3.3.1.3.9 | ENTIBADO DE ZANJA DE 6.01 HASTA 6.50 M | 30d | 2022-12-14 | 2023-01-17 | 169SS | 0d | 11,578.3 | 02.03.01.03.09 |
| 171 | 1.3.3.1.4 | **CAMA DE APOYO PARA PROTECCION DE TUBERIAS** | 61d | 2023-01-06 | 2023-03-17 |  | 0d | 192,548.59 | 02.03.01.04 |
| 172 | 1.3.3.1.4.1 | CAMA DE OVER E=0.30 P/COL. SECUNDARIO DN 200-250mm | 20d | 2023-01-06 | 2023-01-28 | 160FS-15d | 0d | 65,983.81 | 02.03.01.04.01 |
| 173 | 1.3.3.1.4.2 | CAMA DE ARENA E=0.10M. ZANJA P/TUB DN 200-250mm. | 8d | 2023-01-30 | 2023-02-07 | 175FS-5d | 0d | 13,894.48 | 02.03.01.04.02 |
| 174 | 1.3.3.1.4.3 | CAMA DE ARENA E=0.30 Sct P/Tubería DN 200-250mm | 30d | 2023-02-11 | 2023-03-17 | 220SS | 164d | 69,517.32 | 02.03.01.04.03 |
| 175 | 1.3.3.1.4.4 | CAMA DE OVER E=0.30 P/COL.PRINCIPAL DN 315-400mm | 20d | 2023-01-12 | 2023-02-03 | 172SS+5d | 0d | 19,704.31 | 02.03.01.04.04 |
| 176 | 1.3.3.1.4.5 | CAMA DE ARENA E=0.10m. ZANJA P/TUB DN 315-400mm. | 8d | 2023-02-02 | 2023-02-10 | 173FS-5d | 0d | 3,655.05 | 02.03.01.04.05 |
| 177 | 1.3.3.1.4.6 | CAMA DE ARENA E=0.30 SCT P/TUBERÍA DN 315-400mm | 30d | 2023-02-11 | 2023-03-17 | 220SS | 0d | 19,793.62 | 02.03.01.04.06 |
| 178 | 1.3.3.1.5 | **RELLENO, APISONADO Y COMPACTACION ZANJAS** | 25d | 2023-03-29 | 2023-04-26 |  | 0d | 392,234.07 | 02.03.01.05 |
| 179 | 1.3.3.1.5.1 | RELLENO C/MATERIAL DE PRESTAMO DN 200 - 250mm de 1.51 m a 2.00 m Prof. | 25d | 2023-03-29 | 2023-04-26 | 224FS-20d | 0d | 31,561.29 | 02.03.01.05.01 |
| 180 | 1.3.3.1.5.2 | RELLENO C/MATERIAL DE PRESTAMO DN 200 - 250mm de 2.01 m a 2.50 m Prof. | 25d | 2023-03-29 | 2023-04-26 | 179SS | 0d | 43,085.49 | 02.03.01.05.02 |
| 181 | 1.3.3.1.5.3 | RELLENO C/MATERIAL DE PRESTAMO DN 200 - 250mm de 2.51 m a 3.00 m Prof. | 25d | 2023-03-29 | 2023-04-26 | 180SS | 0d | 59,897.25 | 02.03.01.05.03 |
| 182 | 1.3.3.1.5.4 | RELLENO C/MATERIAL DE PRESTAMO DN 200 - 250mm de 3.01 m a 3.50 m Prof. | 25d | 2023-03-29 | 2023-04-26 | 181SS | 0d | 25,054.16 | 02.03.01.05.04 |
| 183 | 1.3.3.1.5.5 | RELLENO C/MATERIAL DE PRESTAMO DN 200 - 250mm de 3.51 m a 4.00 m Prof. | 25d | 2023-03-29 | 2023-04-26 | 182SS | 0d | 42,844.09 | 02.03.01.05.05 |
| 184 | 1.3.3.1.5.6 | RELLENO C/MATERIAL DE PRESTAMO DN 200 - 250mm DE 4.01 M A 4.50 M PROF. | 25d | 2023-03-29 | 2023-04-26 | 183SS | 0d | 37,427.59 | 02.03.01.05.06 |
| 185 | 1.3.3.1.5.7 | RELLENO C/MATERIAL DE PRESTAMO DN 315 - 400MM DE 4.51 M A 5.00 M PROF. | 25d | 2023-03-29 | 2023-04-26 | 184SS | 0d | 26,217.59 | 02.03.01.05.07 |
| 186 | 1.3.3.1.5.8 | RELLENO C/MATERIAL DE PRESTAMO DN 315 - 400mm DE 5,01 M A 5,50 M PROF. | 25d | 2023-03-29 | 2023-04-26 | 185SS | 0d | 47,169.07 | 02.03.01.05.08 |
| 187 | 1.3.3.1.5.9 | RELLENO C/MATERIAL DE PRESTAMO DN 315 - 400mm DE 5,51 M A 6,00 M PROF. | 25d | 2023-03-29 | 2023-04-26 | 186SS | 0d | 50,667.21 | 02.03.01.05.09 |
| 188 | 1.3.3.1.5.10 | RELLENO C/MATERIAL DE PRÉSTAMO DN 315 - 400mm DE 6,01 M A 6,50 M PROF. | 25d | 2023-03-29 | 2023-04-26 | 187SS | 0d | 28,310.33 | 02.03.01.05.10 |

| ID | WBS | Task | Duration | Start | Finish | Predecessors | Total slack | Free slack | Cost | Text1 |
| --- | --- | --- | --- | --- | --- | --- | --- | --- | --- | --- |
| 189 | 1.3.3.1.6 | **ACARREO Y ELIMINACION MATERIAL EXCEDENTE** | 20d | 2022-12-26 | 2023-01-17 |  | 216d |  | 235,991.52 | 02.03.01.06 |
| 190 | 1.3.3.1.6.1 | ACARREO INTERNO, MATERIAL PROCEDEDENTE DE LAS EXCAVACIONES EN ZONA ALEDAÑA | 20d | 2022-12-26 | 2023-01-17 | 156FS-15d | 215d | 0d | 124,516.81 | 02.03.01.06.01 |
| 191 | 1.3.3.1.6.2 | ELIMINACIÓN DE MATERIAL EXCEDENTE D. PROM 5 KM DE LA OBRA | 20d | 2022-12-26 | 2023-01-17 | 190SS | 215d |  | 111,474.71 | 02.03.01.06.02 |
| 192 | 1.3.3.2 | **SUMINISTRO E INSTALACION DE TUBERIA** | 25d | 2023-02-06 | 2023-03-06 |  | 0d |  | 347,439.24 | 02.03.02 |
| 193 | 1.3.3.2.1 | TUBERÍA PVC-U SC NTP ISO 21138 SN 4 DN 200MM INCL. ANILLO + 2% DESPERDICIOS | 25d | 2023-02-06 | 2023-03-06 | 176SS+3d | 0d |  | 158,319.91 | 02.03.02.01 |
| 194 | 1.3.3.2.2 | TUBERÍA PVC-U SC NTP ISO 21138 SN 4 DN 250 INCL. ANILLO + 2% DESPERDICIOS | 25d | 2023-02-06 | 2023-03-06 | 193SS | 0d |  | 16,193.66 | 02.03.02.02 |
| 195 | 1.3.3.2.3 | TUBERÍA PVC-U SC NTP ISO 21138 SN 4 DN 315MM INCL. ANILLO + 2% DESPERDICIOS | 25d | 2023-02-06 | 2023-03-06 | 194SS | 0d |  | 43,592.63 | 02.03.02.03 |
| 196 | 1.3.3.2.4 | TUBERÍA PVC-U SC NTP ISO 21138 SN 4 DN 400MM INCL. ANILLO + 2% DESPERDICIOS | 25d | 2023-02-06 | 2023-03-06 | 195SS | 0d |  | 118,513.91 | 02.03.02.04 |
| 197 | 1.3.3.2.5 | INSTALACIÓN DE TUBERÍA DE PVC P/DESAGÜE DN 200mm | 25d | 2023-02-06 | 2023-03-06 | 196SS | 0d |  | 7,254.01 | 02.03.02.05 |
| 198 | 1.3.3.2.6 | INSTALACIÓN DE TUBERÍA DE PVC P/DESAGÜE DN 250mm. | 25d | 2023-02-06 | 2023-03-06 | 197SS | 0d |  | 366.99 | 02.03.02.06 |
| 199 | 1.3.3.2.7 | INSTALACIÓN DE TUBERÍA DE PVC P/DESAGÜE DN 315 mm | 25d | 2023-02-06 | 2023-03-06 | 198SS | 0d |  | 1,055.53 | 02.03.02.07 |
| 200 | 1.3.3.2.8 | INSTALACIÓN DE TUBERÍA DE PVC P/DESAGÜE DN 400 mm | 25d | 2023-02-06 | 2023-03-06 | 199SS | 0d |  | 2,142.6 | 02.03.02.08 |
| 201 | 1.3.3.3 | **PRUEBAS HIDRAULICAS** | 6d | 2023-03-15 | 2023-03-21 |  | 0d |  | 32,855.18 | 02.03.03 |
| 202 | 1.3.3.3.1 | PRUEBA HIDRAULICA DE TUBERÍA P/DESAGÜE PVC-UF NTP ISO 21138:2010, SN4 DN 200 mm | 6d | 2023-03-15 | 2023-03-21 | 177FS-3d | 0d |  | 23,343.96 | 02.03.03.01 |
| 203 | 1.3.3.3.2 | PRUEBA HIDRAULICA DE TUBERÍA P/DESAGÜE PVC-UF NTP ISO 21138:2010, SN4 DN 250 mm | 6d | 2023-03-15 | 2023-03-21 | 202SS | 161d | 0d | 1,323.04 | 02.03.03.02 |
| 204 | 1.3.3.3.3 | PRUEBA HIDRAULICA DE TUBERÍA P/DESAGÜE PVC-UF NTP ISO 21138:2010, SN4 DN 315 mm | 6d | 2023-03-15 | 2023-03-21 | 203SS | 161d | 0d | 2,866.11 | 02.03.03.03 |
| 205 | 1.3.3.3.4 | PRUEBA HIDRAULICA DE TUBERÍA P/DESAGÜE PVC-UF NTP ISO 21138:2010, SN4 DN 400 mm | 6d | 2023-03-15 | 2023-03-21 | 204SS | 161d |  | 5,322.07 | 02.03.03.04 |
| 206 | 1.3.3.4 | **CAMARAS DE INSPECCION (BUZONES)** | 30d | 2023-02-11 | 2023-03-17 |  | 0d |  | 210,037.15 | 02.03.04 |
| 207 | 1.3.3.4.1 | BUZÓN TIPO I Di=1.2m. HASTA 1,20 m PROF.(ENCOF.EXTER.E INTER.) | 30d | 2023-02-11 | 2023-03-17 | 200SS+5d | 0d |  | 6,368.36 | 02.03.04.01 |
| 208 | 1.3.3.4.2 | BUZÓN TIPO I Di=1.2m. HASTA 1,50 m PROF.(ENCOF.EXTER.E INTER) | 30d | 2023-02-11 | 2023-03-17 | 207SS | 0d |  | 6,933.06 | 02.03.04.02 |
| 209 | 1.3.3.4.3 | BUZÓN TIPO I Di=1.2m. HASTA 2,00 m PROF.(ENCOF.EXTER.E INTER) | 30d | 2023-02-11 | 2023-03-17 | 208SS | 0d |  | 32,172.48 | 02.03.04.03 |
| 210 | 1.3.3.4.4 | BUZÓN TIPO I Di=1.2m. HASTA 2,50 m PROF.(ENCOF.EXTER.E INTER) | 30d | 2023-02-11 | 2023-03-17 | 209SS | 164d | 0d | 27,786.36 | 02.03.04.04 |
| 211 | 1.3.3.4.5 | BUZÓN TIPO I Di=1.2m. HASTA 3,00 m PROF.(ENCOF.EXTER.E INTER) | 30d | 2023-02-11 | 2023-03-17 | 210SS | 164d | 0d | 11,689.72 | 02.03.04.05 |
| 212 | 1.3.3.4.6 | BUZÓN TIPO I Di=1.2m. HASTA 3,50 m PROF.(ENCOF.EXTER.E INTER) | 30d | 2023-02-11 | 2023-03-17 | 211SS | 164d | 0d | 34,133.25 | 02.03.04.06 |
| 213 | 1.3.3.4.7 | BUZÓN TIPO I DI=1.2M. HASTA 4,00 M PROF. (ENCOF.EXTER. E INTER) | 30d | 2023-02-11 | 2023-03-17 | 212SS | 164d | 0d | 7,808.8 | 02.03.04.07 |
| 214 | 1.3.3.4.8 | BUZÓN TIPO II Di=1.5m. HASTA 4,00 m PROF.(ENCOF.EXTER.E INTER) | 30d | 2023-02-11 | 2023-03-17 | 213SS | 164d | 0d | 9,773.77 | 02.03.04.08 |
| 215 | 1.3.3.4.9 | BUZÓN TIPO II Di=1.5m. HASTA 5,00 m PROF.(ENCOF.EXTER.E INTER) | 30d | 2023-02-11 | 2023-03-17 | 214SS | 164d | 0d | 34,546.62 | 02.03.04.09 |
| 216 | 1.3.3.4.10 | BUZÓN TIPO II Di=1.5m. HASTA 5,50 m PROF.(ENCOF.EXTER.E INTER) | 30d | 2023-02-11 | 2023-03-17 | 215SS | 164d | 0d | 24,790.22 | 02.03.04.10 |
| 217 | 1.3.3.4.11 | BUZÓN TIPO II Di=1.5m. HASTA 6,00 m PROF.(ENCOF.EXTER.E INTER) | 30d | 2023-02-11 | 2023-03-17 | 216SS | 164d | 0d | 13,259.36 | 02.03.04.11 |
| 218 | 1.3.3.4.12 | BUZONETA DE CONCRETO F'C=210KG DIAMETRO INTERNO 0.60M | 30d | 2023-02-11 | 2023-03-17 | 217SS | 164d |  | 775.15 | 02.03.04.12 |

| ID | WBS | Task | Type | Duration | Start | Finish | Predecessors | Total slack | Cost | Text1 |
| --- | --- | --- | --- | --- | --- | --- | --- | --- | --- | --- |
| 219 | 1.3.3.5 | **DADO DE ANCLAJE** |  | 30d | 2023-02-11 | 2023-03-17 |  | 0d | 7,238.11 | 02.03.05 |
| 220 | 1.3.3.5.1 | CONCRETO F'C 140 kg/cm2 PARA ANCLAJES Y/O DADOS (CEMENTO MS) |  | 30d | 2023-02-11 | 2023-03-17 | 209SS | 0d | 7,238.11 | 02.03.05.01 |
| 221 | 1.3.3.6 | **CONEXIONES DOMICILIARIAS DE DESAGUE** |  | 26d | 2023-03-22 | 2023-04-20 |  | 0d | 438,700.19 | 02.03.06 |
| 222 | 1.3.3.6.1 | CONEXIONES DOMICILIARIAS PARA DESAGÜE DN 200x160mm |  | 26d | 2023-03-22 | 2023-04-20 | 227FS-15d | 0d | 412,906.65 | 02.03.06.01 |
| 223 | 1.3.3.6.2 | CONEXIONES DOMICILIARIAS PARA DESAGÜE DN 250X160MM |  | 26d | 2023-03-22 | 2023-04-20 | 222SS | 0d | 4,234.94 | 02.03.06.02 |
| 224 | 1.3.3.6.3 | CONEXIONES DOMICILIARIAS PARA DESAGÜE DN 315x160mm |  | 26d | 2023-03-22 | 2023-04-20 | 223SS | 0d | 21,558.6 | 02.03.06.03 |
| 225 | 1.3.3.7 | **ROTURA Y REPOSICION DE PAVIMENTOS** |  | 34d | 2023-03-16 | 2023-04-24 |  | 0d | 26,539.05 | 02.03.07 |
| 226 | 1.3.3.7.1 | CORTE DE VEREDA P/CONEXIÓN DOMICILIARIA |  | 20d | 2023-03-16 | 2023-04-07 | 202SS+1d | 0d | 8,620.47 | 02.03.07.01 |
| 227 | 1.3.3.7.2 | DEMOLICIÓN DE VEREDA P/CONEXIÓN DOMICILIARIA |  | 20d | 2023-03-16 | 2023-04-07 | 226SS | 0d | 2,885.41 | 02.03.07.02 |
| 228 | 1.3.3.7.3 | CONCRETO F'C 175 kg/cm2 PARA VEREDAS E=10cm. (CEMENTO MS) |  | 8d | 2023-04-15 | 2023-04-24 | 224FS-5d | 132d | 15,033.17 | 02.03.07.03 |
| 229 | 1.3.3.8 | **INTERFERENCIAS** |  | 120d | 2022-12-08 | 2023-04-26 |  | 131d | 65,801.41 | 02.03.08 |
| 230 | 1.3.3.8.1 | EMPALMES DE TUBERÍAS DN 200/250/315/400MM A BUZÓN EXISTENTE EN SERVICIO |  | 25d | 2023-02-06 | 2023-03-06 | 196SS | 174d | 5,237.28 | 02.03.08.01 |
| 231 | 1.3.3.8.2 | DEMOLICIÓN DE BUZONES EXISTENTES |  | 30d | 2022-12-08 | 2023-01-11 | 156SS | 220d | 20,796.3 | 02.03.08.02 |
| 232 | 1.3.3.8.3 | COLOCACION DE TUBERIA DE PVC-Ø4" SAL PROVISIONAL DE ALCANTARILLADO PARA CONTINUIDAD DEL SERVICIO |  | 120d | 2022-12-08 | 2023-04-26 | 156SS | 130d | 13,119.68 | 02.03.08.03 |
| 233 | 1.3.3.8.4 | TRANSPORTE DE MATERIALES A OBRA |  | 60d | 2022-12-08 | 2023-02-15 | 156SS | 190d | 26,648.15 | 02.03.08.04 |
| 234 | 1.4 | FIN DEL PROYECTO | milestone | 0d | 2023-03-13 | 2023-03-13 | 75 | 168d |  |  |
